# Transmisson Outage Plan - draft 2024

Schedule from MS Project, 2022-01-01 to 2024-11-15.
Eirgrid PLC

## Calendars

- Standard: Mon-Fri 08:00-12:00, 13:00-17:00; Sat-Sun off.

## Resources

| Resource |
| --- |
| 216/2021 |
| 392/2021 |
| NO OUTAGE REQ |
| tbc |
| n/a |
| 083/2021 |
| 302/2021 |
| 303/2021 |
| 223/2021 |
| 025/2021 |
| tbc second set |
| 248/2021 |
| 247/2021 |
| 395/2021 |
| september date tbc |
| 340/2021 |
| 417/2021 |
| 119/2021 |
| 346/2021 |

## Schedule

| ID | Task | Type | Duration | Start | Finish | Text1 | Text3 | Text4 | Text2 |
| --- | --- | --- | --- | --- | --- | --- | --- | --- | --- |
| 1 | CIRCUIT BREAKER FAILS | manual | 0.2w | 2022-01-01 | 2022-01-01 | KELLS | PROJ | 275 |  |
| 2 | CIRCUIT BREAKER FAILS SCHEME ( 13 SETS ) | manual | 0.2w | 2022-01-01 | 2022-01-01 | KILROOT | PROJ | 275 |  |
| 3 | MF100 MAINT BALLYVALLAGH B | manual | 0.2w | 2022-01-01 | 2022-01-01 | KELLS | MAINT | 110 |  |
| 4 | GD5 MAINT | manual | 1d | 2022-01-01 | 2022-01-01 | BALLYLUMFORD | MAINT | 275 |  |
| 5 | IBTX2 MINOR AND MG55 MAINT | manual | 3w | 2024-01-03 | 2024-01-23 | HANNAHSTOWN | MAINT | 275 |  |
| 6 | defect repairs pole 87 | manual | 3.6w | 2024-01-03 | 2024-01-26 | TANDRAGEE | OHL | 110 | BANBRIDGE B |
| 7 | MD50 MAINT (BUS-COUPLER ) | manual | 1d? | 2022-01-01 | 2022-01-01 | BALLYLUMFORD | MAINT | 110 |  |
| 8 | Transformer '3' cable duct sealing at 33kv letterbox | manual | 1d? | 2022-01-01 | 2022-01-01 | BALLYMENA | PROJ | 110 |  |
| 9 | SECTION 1 BUSBAR | manual | 1d? | 2022-01-01 | 2022-01-01 | BALLYVALLAGH | MAINT | 110 |  |
| 10 | SECTION 2 BUSBAR | manual | 1d? | 2022-01-01 | 2022-01-01 | BALLYVALLAGH | MAINT | 110 |  |
| 11 | SECTION 1R BUSBAR ( ISOLATORS) | manual | 1d? | 2022-01-01 | 2022-01-01 | CASTLEREAGH | MAINT | 110 |  |
| 12 | SECTION 1L BUSBAR (ISOLATORS ) | manual | 1d? | 2022-01-01 | 2022-01-01 | CASTLEREAGH | MAINT | 110 |  |
| 13 | SECTION 2R BUSBAR ( ISOLATORS ) | manual | 1d? | 2022-01-01 | 2022-01-01 | CASTLEREAGH | MAINT | 110 |  |
| 14 | SECTION 2L BUSBAR ( ISOLATORS ) | manual | 1d? | 2022-01-01 | 2022-01-01 | CASTLEREAGH | MAINT | 110 |  |
| 15 | COOLKEERAGH MAIN SECTION A2 BUSBAR (BUSBAR) - | manual | 1d? | 2022-01-01 | 2022-01-01 | COOLKEERAGH | MAINT | 275 |  |
| 16 | COOLKEERAGH MAIN SECTION 2L BUSBAR (BUSBAR) - | manual | 1d? | 2022-01-01 | 2022-01-01 | COOLKEERAGH | MAINT | 110 |  |
| 17 | COOLKEERAGH MAIN SECTION 2R BUSBAR (BUSBAR) - | manual | 1d? | 2022-01-01 | 2022-01-01 | COOLKEERAGH | MAINT | 110 |  |
| 18 | 110KV ISOLATORS SECTION 1L | manual | 1d? | 2022-01-01 | 2022-01-01 | HANNAHSTOWN | MAINT | 110 |  |
| 19 | 110KV ISOLATORS SECTION 1R | manual | 1d? | 2022-01-01 | 2022-01-01 | HANNAHSTOWN | MAINT | 110 |  |
| 20 | SECTION 1L BUSBAR ( 3 ISOLATORS) | manual | 1d? | 2022-01-01 | 2022-01-01 | KELLS | MAINT | 110 |  |
| 21 | SECTION 1R BUSBAR ( 4 ISOLATORS ) | manual | 1d? | 2022-01-01 | 2022-01-01 | KELLS | MAINT | 110 |  |
| 22 | SECTION 2R BUSBAR ( 4 ISOLATORS) | manual | 1d? | 2022-01-01 | 2022-01-01 | KELLS | MAINT | 110 |  |
| 23 | GJ50 MAINT | manual | 1d? | 2022-01-01 | 2022-01-01 | KILROOT | MAINT | 275 |  |
| 24 | GJ50 MAINT | manual | 1d? | 2022-01-01 | 2022-01-01 | KILROOT | MAINT | 275 |  |
| 25 | 10M0 MAINT | manual | 1d? | 2022-01-01 | 2022-01-01 | OMAGH | MAINT | 110 |  |
| 26 | 3M0 MAINT | manual | 1d? | 2022-01-01 | 2022-01-01 | OMAGH | MAINT | 110 |  |
| 27 | 9M0 MAINT | manual | 1d? | 2022-01-01 | 2022-01-01 | OMAGH | MAINT | 110 |  |
| 28 | SECTION '1L' ISOLATORS - MAINTENANCE | manual | 1d? | 2022-01-01 | 2022-01-01 | TANDRAGEE | MAINT | 275 |  |
| 29 | SECTION '2R' ISOLATOR | manual | 1d? | 2022-01-01 | 2022-01-01 | TANDRAGEE | MAINT | 110 |  |
| 30 | SECTION '2L' ISOLATORS - MAINTENANCE | manual | 1d? | 2022-01-01 | 2022-01-01 | TANDRAGEE | MAINT | 110 |  |
| 31 | SECTION '1R' ISOLATORS - MAINTENANCE | manual | 1d? | 2022-01-01 | 2022-01-01 | TANDRAGEE | MAINT | 110 |  |
| 32 | 5K0 MAINT | manual | 1d? | 2022-01-01 | 2022-01-01 | DRUMNAKELLY | MAINT | 110 |  |
| 33 | 7K0 MAINT | manual | 1d? | 2022-01-01 | 2022-01-01 | DRUMNAKELLY | MAINT | 110 |  |
| 34 | SPS SCHEME COMMSSIONING | manual | 6w | 2024-01-04 | 2024-02-14 | COOLKEERAGH | PROJ | 275 | MAGHERAFELT |
| 35 | CIRCUIT BREAKER FAILS SCHEME ( 7 SETS ) | manual | 1min | 2024-01-04 | 2024-01-04 | MAGHERAFELT | PROJ | 275 |  |
| 36 | RUNBACK SCHEME TESTING AND COMMISSIONING | manual | 6w | 2024-01-04 | 2024-02-14 | MAGHERAFELT | PROJ | 275 |  |
| 37 | LOADSHEDDING (RUNBACK SCHEME) - 3 LOADSHEDDING RELAYS | manual | 1d | 2024-01-08 | 2024-01-08 | COOLKEERAGH | PROJ | 275 |  |
| 38 | 1H0 MAINT BUS-COUPLER INC 1H2 MAINT | manual | 1d | 2022-01-01 | 2022-01-01 | COOLKEERAGH | MAINT | 110 |  |
| 39 | MF5 MAINT BUCSOUPLER | manual | 1w | 2024-01-08 | 2024-01-12 | KELLS | MAINT | 110 |  |
| 40 | REACTOR 1 commissiong and agile WORKS (IBTx outage one week at end) | manual | 8w | 2024-01-08 | 2024-03-01 | TAMNAMORE | PROJ | 275 |  |
| 41 | ARCING HORN DEFECT REPAIRS | manual | 1d | 2022-01-01 | 2022-01-01 | TANDRAGEE | OHL | 110 | NEWRY B |
| 42 | TRANSFORMER TX B 2nd stage replacement | manual | 6w | 2024-01-08 | 2024-02-16 | GLENGORMLEY | PROJ | 110 |  |
| 43 | NEW GENERATOR 7 BAY proximity to test cable on gen 7 | manual | 1d | 2022-01-01 | 2022-01-01 | KILROOT | PROJ | 275 |  |
| 44 | MF95 MAINT BUS COUPLER | manual | 1w | 2024-01-10 | 2024-01-16 | KELLS | MAINT | 110 |  |
| 45 | TOWER PAINTING 1 ARM OVER HOUSE, ARCING HORN DEFECT REPAIRS | manual | 3d | 2024-01-10 | 2024-01-12 | TANDRAGEE | OHL | 110 | NEWRY A |
| 46 | MW5 MAINT BUS-COUPLER | manual | 1w | 2024-01-15 | 2024-01-19 | DROMORE | MAINT | 110 |  |
| 47 | GA5 MAINT | manual | 5d | 2024-01-15 | 2024-01-19 | COOLKEERAGH | MAINT | 275 |  |
| 48 | MP40 BAY PQ MONITOR AND WIRING MODIFICATIONS | manual | 3w | 2024-01-15 | 2024-02-02 | TAMNAMORE | PROJ | 110 | CREAGH |
| 49 | MP40 MAINT CREAGH | manual | 1w | 2024-01-15 | 2024-01-19 | TAMNAMORE | MAINT | 110 |  |
| 50 | POLE REPLACEMENTS WORKS | manual | 1w | 2024-01-18 | 2024-01-24 | TAMNAMORE | OHL | 110 | CREAGH |
| 51 | GC10 MAINT | manual | 5d | 2024-01-22 | 2024-01-26 | CASTLEREAGH | MAINT | 275 |  |
| 52 | 6L0 MAINT | manual | 2d | 2024-01-22 | 2024-01-23 | COLERAINE | MAINT | 110 |  |
| 53 | SECTION A3 ISOLATOR GD18 & Earth Switch EG69 | manual | 2d | 2024-01-22 | 2024-01-23 | BALLYLUMFORD | MAINT | 275 |  |
| 54 | 7M0 MAINT | manual | 2d | 2024-01-23 | 2024-01-24 | OMAGH | MAINT | 110 |  |
| 55 | TX2 33 KV CIRCUIT BREAKER DISCHARGE REPAIRS | manual | 3d | 2024-01-24 | 2024-01-26 | LISAGHMORE | MAINT | 110 |  |
| 56 | SECTION A3 ISOLATOR GD36 | manual | 2d | 2024-01-24 | 2024-01-25 | BALLYLUMFORD | MAINT | 275 |  |
| 57 | 8M0 MAINT | manual | 2d | 2024-01-25 | 2024-01-26 | OMAGH | MAINT | 110 |  |
| 58 | NEW GENERATOR 7 BAY connect to section A2 | manual | 2d | 2024-01-25 | 2024-01-26 | KILROOT | PROJ | 275 |  |
| 59 | NEW GENERATOR 7 BAY connect to section A1 & scaffolding for final connection | manual | 5d | 2024-01-26 | 2024-02-01 | KILROOT | PROJ | 275 |  |
| 60 | TANDRAGEE IBTX1 MINOR INC GB45 & MB40 | manual | 2w | 2024-01-26 | 2024-02-08 | TANDRAGEE | MAINT | 275 |  |
| 61 | GC25 MAINT | manual | 5d | 2024-01-29 | 2024-02-02 | CASTLEREAGH | MAINT | 275 |  |
| 62 | MP35 MAINT BUSCOUPLER | manual | 1w | 2024-01-29 | 2024-02-02 | TAMNAMORE | MAINT | 110 |  |
| 63 | TANDRAGEE IBTX2 MINOR INC GB75 & MB60 | manual | 2w | 2024-01-29 | 2024-02-09 | TANDRAGEE | MAINT | 275 |  |
| 64 | 8L0 MAINT | manual | 2d | 2024-01-29 | 2024-01-30 | COLERAINE | MAINT | 110 |  |
| 65 | SECTION A1 ISOLATOR GD19 & Earth Switch EG70 | manual | 2d | 2024-01-29 | 2024-01-30 | BALLYLUMFORD | MAINT | 275 |  |
| 66 | OHL Pole changes AND TOWER PAINTING | manual | 2d | 2024-01-31 | 2024-02-01 | COOLKEERAGH | OHL | 110 | COLERAINE |
| 67 | SECTION A1 ISOLATOR GD38 & Earth Switch EG78 | manual | 2d | 2024-01-31 | 2024-02-01 | BALLYLUMFORD | MAINT | 275 |  |
| 68 | cable sheath tests | manual | 2d | 2024-02-02 | 2024-02-04 | KELLS | MAINT | 110 | Glengormley 'B' |
| 69 | cable sheath tests | manual | 2d | 2024-02-02 | 2024-02-04 | KELLS | MAINT | 110 | Glengormley 'A' |
| 70 | NEW GENERATOR 7 BAY connect CSE's to CVT & scaffolding removal . Final connection | manual | 5d | 2024-02-02 | 2024-02-08 | KILROOT | PROJ | 275 |  |

| ID | Task | Type | Duration | Start | Finish | Text1 | Text3 | Text4 | Text2 |
| --- | --- | --- | --- | --- | --- | --- | --- | --- | --- |
| 71 | GC5 MAINT | manual | 5d | 2024-02-05 | 2024-02-09 | CASTLEREAGH | MAINT | 275 |  |
| 72 | MX5 MAINT BUSCOUPLER | manual | 5d | 2024-02-05 | 2024-02-09 | DRUMQUIN | MAINT | 110 |  |
| 73 | MN25 MAINT | manual | 3d | 2024-02-05 | 2024-02-07 | CREAGH | MAINT | 110 |  |
| 74 | POLE REPLACEMENTS WORKS | manual | 3d | 2024-02-05 | 2024-02-07 | TANDRAGEE | OHL | 110 | LISBURN A |
| 75 | GD70 maintenance | manual | 5d | 2024-02-05 | 2024-02-09 | BALLYLUMFORD | MAINT | 275 | Magherafelt |
| 76 | GD70 PQ MONITOR AND WIRING MODIFICATIONS | manual | 1w | 2024-02-05 | 2024-02-09 | BALLYLUMFORD | PROJ | 275 | MAGHERAFELT |
| 77 | 52V0 MAINT | manual | 1w | 2024-02-05 | 2024-02-09 | LIMAVADY | MAINT | 110 |  |
| 78 | MN5 MAINT | manual | 2d | 2024-01-18 | 2024-01-19 | CREAGH | MAINT | 110 |  |
| 79 | D/C TOWERS T39 & T40 | manual | 1d | 2024-02-05 | 2024-02-05 | KELLS | OHL | 110 | CREAGH |
| 80 | BUSCOUPLER COMMISSIONING WORKS /WIRING MODIFICATIONS | manual | 3d | 2024-02-06 | 2024-02-08 | GORT | PROJ | 110 |  |
| 81 | D/C TOWERS T39 & T40 | manual | 3d | 2024-02-07 | 2024-02-09 | KELLS | OHL | 110 | RASHARKIN |
| 82 | MF31 maintenance ( bus section isol. assoc with Rasharkin cct ) | manual | 2d | 2024-02-07 | 2024-02-08 | KELLS | OHL | 110 |  |
| 83 | NEW GENERATOR 7 BAY cable restest | manual | 1d | 2022-01-01 | 2022-01-01 | KILROOT | PROJ | 275 |  |
| 84 | 51V0 MAINT | manual | 1w | 2024-02-12 | 2024-02-16 | LIMAVADY | MAINT | 110 |  |
| 85 | GC45 MAINT | manual | 5d | 2024-02-12 | 2024-02-16 | CASTLEREAGH | MAINT | 275 |  |
| 86 | IBTX4 MINOR | manual | 1w | 2024-02-12 | 2024-02-16 | CASTLEREAGH | MAINT | 275 |  |
| 87 | 110KV GROUP ALARMS T602M | manual | 3d | 2024-02-12 | 2024-02-14 | KELLS | PROJ | 110 |  |
| 88 | reaxtor 3 TR3 point of wave breaker testing D shaw | manual | 3d | 2024-02-15 | 2024-02-19 | HANNAHSTOWN | PROJ | 275 |  |
| 89 | IBTX4 110KV NEW BAY CONSTRUCTION | manual | 100d | 2024-02-19 | 2024-07-05 | HANNAHSTOWN | PROJ | 110 |  |
| 90 | MC20 MAINT ( ROSEBANK B) | manual | 5d | 2024-02-19 | 2024-02-23 | CASTLEREAGH | MAINT | 110 |  |
| 91 | KEL INTERBUS TRANSFORMER 1 MINOR MAINT INCLUDING TAPCHANGER UPGRADE ( RX COOLER UPGRADES) | manual | 10w | 2024-02-19 | 2024-04-26 | KELLS | MAINT | 275 |  |
| 92 | MESH CORNER PROTECTION (PROJECTS) - IBTX 1 PROTECTION CHANGE , REACTOR PROTECTION REQUIRES . ( IBTX1 , BPS CIRCUIT GF55 & GF115) | manual | 10w | 2024-02-19 | 2024-04-26 | KELLS |  | 275 | BPS |
| 93 | Kells ibtx1 minor and 275kv isolator refurbs AND MF45 MAINT | manual | 2w | 2024-02-19 | 2024-03-01 | KELLS | MAINT | 275 |  |
| 94 | GF115 MAINT | manual | 1w | 2024-02-19 | 2024-02-23 | KELLS | MAINT | 275 |  |
| 95 | GF55 MAINT | manual | 1w | 2024-02-19 | 2024-02-23 | KELLS | MAINT | 275 |  |
| 96 | 53V0 MAINT | manual | 1w | 2024-02-19 | 2024-02-23 | LIMAVADY | MAINT | 110 |  |
| 97 | HOTSPOT WORKS ON THE L2 PHASE CVT CONNECTION 22DEGREES | manual | 1d | 2024-02-20 | 2024-02-20 | TAMNAMORE | MAINT | 275 | TANDAGREE 'B' |
| 98 | GC50 MAINT | manual | 5d | 2024-02-26 | 2024-03-01 | CASTLEREAGH | MAINT | 275 |  |
| 99 | TOWER PAINTING & OHL WORKS | manual | 2w | 2024-02-26 | 2024-03-08 | BALLYLUMFORD | OHL | 275 | KELLS |
| 100 | 1D0 MAINT | manual | 3d | 2024-02-26 | 2024-02-28 | DONEGALL | MAINT | 110 |  |
| 101 | TX C MINOR NO SFRA | manual | 1w | 2024-02-26 | 2024-03-01 | DONEGALL | MAINT | 110 |  |
| 102 | MG10 MAINT DONEGALL 'A' CIRCUIT | manual | 1w | 2024-02-26 | 2024-03-01 | HANNAHSTOWN | MAINT | 110 |  |
| 103 | INTERBUS 1 MINOR | manual | 1w | 2024-02-26 | 2024-03-01 | TAMNAMORE | MAINT | 275 |  |
| 104 | 54V0 MAINT | manual | 1w | 2024-02-26 | 2024-03-01 | LIMAVADY | MAINT | 110 |  |
| 105 | TX A MINOR, INC TAPCHANGER FLUSH | manual | 3w | 2024-03-04 | 2024-03-22 | KNOCK | MAINT | 110 |  |
| 106 | TX A MINOR MAINT | manual | 1w | 2024-03-04 | 2024-03-08 | BELFAST NORTH MAIN | MAINT | 110 |  |
| 107 | TX 1 MAJOR NO SFRA | manual | 2w | 2024-03-04 | 2024-03-15 | LIMAVADY | MAINT | 110 |  |
| 108 | CONTROL PANEL WIRING | manual | 2d | 2024-03-04 | 2024-03-05 | BALLYLUMFORD | PROJ | 275 |  |
| 109 | CONTROL PANEL REFURBISHMENT - PROJECT INCLUDING GROUP ALARMS | manual | 4mo | 2024-03-04 | 2024-06-21 | BALLYLUMFORD | PROJ | 275 |  |
| 110 | POLE REPLACEMENTS WORKS | manual | 1w | 2024-03-04 | 2024-03-08 | COLERAINE | OHL | 110 | LIMAVADY |
| 111 | TX 1 INSTALLATION | manual | 10w | 2024-03-04 | 2024-05-10 | GORT | PROJ | 110 |  |
| 112 | (CONTROL PANEL REFURBISHMENT) - | manual | 3min | 2024-03-04 | 2024-03-04 | MAGHERAFELT | PROJ | 275 |  |
| 113 | TX B MINOR MAINT | manual | 1w | 2024-03-11 | 2024-03-15 | BELFAST NORTH MAIN | MAINT | 110 |  |
| 114 | tower painting | manual | 1w | 2024-03-11 | 2024-03-15 | COLERAINE | OHL | 110 | LOGUESTOWN 'A' |
| 115 | 2D0 MAINT | manual | 3d | 2024-03-11 | 2024-03-13 | DONEGALL | MAINT | 110 |  |
| 116 | TX B MAJOR MAINT | manual | 3w | 2024-03-11 | 2024-03-29 | DONEGALL | MAINT | 110 |  |
| 117 | MG50 MAINT DONEGALL 'B' CIRCUIT | manual | 1w | 2024-03-11 | 2024-03-15 | HANNAHSTOWN | MAINT | 110 |  |
| 118 | GP5 MAINT MAGHERAFELT 'B' | manual | 1w | 2024-03-11 | 2024-03-15 | TAMNAMORE | MAINT | 275 |  |
| 119 | POLE REPLACEMENT WORKS | manual | 1w | 2024-03-11 | 2024-03-15 | COLERAINE | OHL | 110 | COOLKEERAGH |
| 120 | OHL Pole changes AND TOWER PAINTING | manual | 1w | 2024-03-11 | 2024-03-15 | COOLKEERAGH | OHL | 110 | COLERAINE |
| 121 | GIS cable works GT1 (only), Includes CT replacements on the both circuits | manual | 7w | 2024-03-18 | 2024-05-03 | BALLYLUMFORD | PROJ | 110 |  |
| 122 | PUBLIC HOLIDAY | manual | 1d | 2024-03-18 | 2024-03-18 | BANK HOLIDAY/PUBLIC HOLS | HOL | SPARE |  |
| 123 | TX4 MAJOR 1ST MAINTENANCE AND COOLER OIL LEAK REPAIRS | manual | 2w | 2024-03-19 | 2024-04-01 | BALLYMENA | MAINT | 110 |  |
| 124 | TX1 MAJOR MAINT | manual | 10d | 2024-03-19 | 2024-04-01 | BALLYNAHINCH | MAINT | 110 |  |
| 125 | MC85 MAINT ( BNH A) | manual | 5d | 2024-03-19 | 2024-03-25 | CASTLEREAGH | MAINT | 110 |  |
| 126 | POLE REPLACEMENTS WORKS | manual | 1w | 2024-03-19 | 2024-03-25 | KELLS | OHL | 110 | BALLYMENA 'B' |
| 127 | TX 2 MAJOR INC SFRA | manual | 2w | 2024-03-19 | 2024-04-01 | LIMAVADY | MAINT | 110 |  |
| 128 | tower painting AND POLE REPLACEMENTS | manual | 2w | 2024-03-19 | 2024-04-01 | COOLKEERAGH | OHL | 110 | LIMAVADY |
| 129 | TX B MINOR, INC TAPCHANGER FLUSH | manual | 3w | 2024-03-12 | 2024-04-01 | KNOCK | MAINT | 110 |  |
| 130 | 14H0 MAINT LISAGHMORE A | manual | 1w | 2024-03-25 | 2024-03-29 | COOLKEERAGH | MAINT | 110 |  |
| 131 | TX1 MAJOR INC SFRA | manual | 10d | 2024-03-25 | 2024-04-05 | LISAGHMORE | MAINT | 110 |  |
| 132 | CLOCKCHANGE | manual | 1d | 2024-03-31 | 2024-03-31 | CLOCKCHANGE | TIME | SPARE |  |
| 133 | PUBLIC HOLIDAY | manual | 2d | 2024-04-01 | 2024-04-02 | BANK HOLIDAY/PUBLIC HOLS | HOL | SPARE |  |
| 134 | TX2 MAJOR MAINT | manual | 7d | 2024-04-03 | 2024-04-11 | BALLYNAHINCH | MAINT | 110 |  |
| 135 | MC95 MAINT ( BNH B) | manual | 5d | 2024-04-03 | 2024-04-09 | CASTLEREAGH | MAINT | 110 |  |
| 136 | POLE REPLACEMENTS WORKS | manual | 1w | 2024-04-03 | 2024-04-09 | TANDRAGEE | OHL | 110 | BANBRIDGE A |
| 137 | TOWER PAINTING | manual | 1.2w | 2024-04-03 | 2024-04-10 | BALLYCRONANMORE | OHL | 275 | HANNAHSTOWN A |
| 138 | IBTX2 MINOR | manual | 1w | 2024-04-08 | 2024-04-12 | CASTLEREAGH | MAINT | 275 |  |
| 139 | POLE REPLACEMENTS WORKS | manual | 1d | 2024-04-08 | 2024-04-08 | TANDRAGEE | OHL | 110 | BANBRIDGE B |
| 140 | tower painting AND POLE REPLACEMENTS 272 & 277 | manual | 1w | 2024-04-08 | 2024-04-12 | COOLKEERAGH | OHL | 110 | killymalaght |

| ID | Task | Type | Duration | Start | Finish | Text1 | Text2 | Text3 | Text4 |
| --- | --- | --- | --- | --- | --- | --- | --- | --- | --- |
| 141 | 8H0 BAY PQ MONITOR AND WIRING MODIFCATIONS | manual | 3w | 2024-04-08 | 2024-04-26 | COOLKEERAGH | killymalaght | PROJ | 110 |
| 142 | PST MAJOR OVERHAUL reschedule | manual | 3w | 2024-04-08 | 2024-04-26 | ENNISKILLEN |  | MAINT | 110 |
| 143 | MR10 MAINT | manual | 1w | 2024-04-08 | 2024-04-12 | KILLYMALAGHT | SLIEVEKIRK | MAINT | 110 |
| 144 | MR6, MR7 AND MR9 | manual | 1w | 2024-04-08 | 2024-04-12 | KILLYMALAGHT |  | MAINT | 110 |
| 145 | IBTX1 MINOR | manual | 1w | 2024-04-08 | 2024-04-12 | COOLKEERAGH |  | MAINT | 275 |
| 146 | 12H0 MAINT LISAGHMORE B | manual | 1w | 2024-04-15 | 2024-04-19 | COOLKEERAGH |  | MAINT | 110 |
| 147 | TX2 MINOR INC DOBLE AND TC FLUSH | manual | 8d | 2024-04-15 | 2024-04-24 | LISAGHMORE |  | MAINT | 110 |
| 148 | TOWER PAINTING | manual | 1w | 2024-04-15 | 2024-04-19 | TANDRAGEE | WARINGSTOWN A | OHL | 110 |
| 149 | INTERBUS 2 MINOR & GP75 & MP60 | manual | 1w | 2024-04-22 | 2024-04-26 | TAMNAMORE |  | MAINT | 275 |
| 150 | TOWER PAINTING | manual | 1w | 2024-04-22 | 2024-04-26 | TANDRAGEE | WARINGSTOWN B | OHL | 110 |
| 151 | 3K0 sf6 repairs | manual | 1w | 2024-04-22 | 2024-04-26 | DRUMNAKELLY |  | MAINT | 110 |
| 152 | GC33, EG44 AND HANNAHSTOWN 'B' CVT | manual | 1w | 2024-04-11 | 2024-04-18 | CASTLEREAGH | HAN B | MAINT | 275 |
| 153 | reactor 1 steps entexol | manual | 1d | 2024-04-25 | 2024-04-25 | KELLS |  | PROJ | 110 |
| 154 | IBTX4 110KV NEW GANTRY CONSTRUCTION AT GG8 | manual | 1d | 2022-01-01 | 2022-01-01 | HANNAHSTOWN |  | PROJ | 275 |
| 155 | IBTX4 (275kV mesh closed, Lisburn circuit may need to be returned to service during high Moyle flows) IBTX1 AND liSBURN | manual | 3w | 2024-04-27 | 2024-05-16 | HANNAHSTOWN |  | PROJ | 110 |
| 156 | GVH TX WIRING MODIFICATIONS, POW adjustments | manual | 3w | 2024-04-29 | 2024-05-17 | GARVAGH |  | PROJ | 110 |
| 157 | BUSCOUPLER COMMISSIONING WORKS /WIRING MODIFICATIONS | manual | 3d | 2024-04-29 | 2024-05-01 | GARVAGH |  | PROJ | 110 |
| 158 | reactor 2 steps entexol | manual | 1d | 2024-04-29 | 2024-04-29 | KELLS |  | PROJ | 110 |
| 159 | CLIMBING INSPECTIONS / PAINTING | manual | 1w | 2024-05-06 | 2024-05-10 | FINAGHY | DONEGALL A | OHL | 110 |
| 160 | CLIMBING INSPECTIONS / PAINTING | manual | 1w | 2024-05-06 | 2024-05-10 | KELLS | ANTIRM A | OHL | 110 |
| 161 | IBTX1 MINOR | manual | 1w | 2024-05-06 | 2024-05-10 | BALLYLUMFORD |  | MAINT | 275 |
| 162 | PUBLIC HOLIDAY | manual | 1d | 2024-05-06 | 2024-05-06 | BANK HOLIDAY/PUBLIC HOLS |  | HOL | SPARE |
| 163 | 16H0 MAINT SPRINGTOWN B + 16H3 & CVT & CSE's - tower CSE's ?? | manual | 1w | 2024-05-07 | 2024-05-13 | COOLKEERAGH |  | MAINT | 110 |
| 164 | TX2 MINOR MAINT | manual | 1w | 2024-05-07 | 2024-05-13 | SPRINGTOWN |  | MAINT | 110 |
| 165 | TX A MAJOR MAINT INC SFRA | manual | 2w | 2024-05-07 | 2024-05-18 | CARMONEY |  | MAINT | 110 |
| 166 | 5C0 MAINT | manual | 3d | 2024-05-07 | 2024-05-09 | CARMONEY |  | MAINT | 110 |
| 167 | OHL WORKS | manual | 1w | 2024-05-13 | 2024-05-17 | BALLYLUMFORD | BALLYVALLAGH B | OHL | 110 |
| 168 | CLIMBING INSPECTIONS / PAINTING | manual | 1w | 2024-05-13 | 2024-05-17 | FINAGHY | DONEGALL B | OHL | 110 |
| 169 | HAN B CSE MAINT | manual | 1d | 2024-05-13 | 2024-05-13 | FINAGHY |  | MAINT | 110 |
| 170 | CLIMBING INSPECTIONS / PAINTING | manual | 1w | 2024-05-13 | 2024-05-17 | KELLS | ANTIRM B | OHL | 110 |
| 171 | GC70 MAINT | manual | 5d | 2024-05-13 | 2024-05-17 | CASTLEREAGH |  | MAINT | 275 |
| 172 | OHL AND TOWER PAINTING | manual | 2w | 2024-05-13 | 2024-05-24 | CASTLEREAGH | TANDRAGEE | OHL | 275 |
| 173 | GC70/GC75 PQ MONITOR AND WIRING MODIFICATIONS | manual | 3w | 2024-05-13 | 2024-05-31 | CASTLEREAGH | TANDRAGEE | PROJ | 275 |
| 174 | OHL AND TOWER PAINTING | manual | 1w | 2024-05-13 | 2024-05-17 | HANNAHSTOWN | BALLYCRONANMORE | OHL | 275 |
| 175 | IBTX4 CORNER AND BYC CIRCUIT | manual | 8w | 2024-05-13 | 2024-07-05 | HANNAHSTOWN | BYC | PROJ | 275 |
| 176 | POLE REPLACEMENTS WORKS | manual | 1w | 2024-05-13 | 2024-05-17 | STRABANE | killymalaght | OHL | 110 |
| 177 | GIS cable works GT2 (only), Includes CT replacements on the both circuits | manual | 6w | 2024-05-20 | 2024-06-28 | BALLYLUMFORD |  | PROJ | 110 |
| 178 | TX1 Major inc MR upgrade | manual | 3w | 2024-05-27 | 2024-06-14 | NEWTOWNARDS |  | MAINT | 110 |
| 179 | PUBLIC HOLIDAY | manual | 1d | 2024-05-27 | 2024-05-27 | BANK HOLIDAY/PUBLIC HOLS |  | HOL | SPARE |
| 180 | 6S0 MAINT /REPLACEMENT AND OMAGH A CVT | manual | 7w | 2024-05-27 | 2024-07-12 | STRABANE | Omagh A | MAINT | 110 |
| 181 | MW10 MAINT DRUMQUIN CCT | manual | 1w | 2024-06-03 | 2024-06-07 | DROMORE |  | MAINT | 110 |
| 182 | TX 1 MAJOR INC SFRA | manual | 1w | 2024-06-03 | 2024-06-07 | DRUMQUIN |  | MAINT | 110 |
| 183 | MX10 MAINT TX1 | manual | 1w | 2024-06-03 | 2024-06-07 | DRUMQUIN |  | MAINT | 110 |
| 184 | MX15 MAINT DROMORE | manual | 1w | 2024-06-03 | 2024-06-07 | DRUMQUIN |  | MAINT | 110 |
| 185 | TX B MINOR MAINT | manual | 1w | 2024-06-03 | 2024-06-07 | CARMONEY |  | MAINT | 110 |
| 186 | 6C0 MAINT | manual | 3d | 2024-06-03 | 2024-06-05 | CARMONEY |  | MAINT | 110 |
| 187 | 1M0/2M0 BAY PQ MONITOR AND WIRING MODIIFCATIONS | manual | 3w | 2024-06-03 | 2024-06-21 | OMAGH | DUNGANNON 'A' | PROJ | 110 |
| 188 | ISOLATOR REFURBS | manual | 4w | 2024-06-03 | 2024-06-28 | STRABANE |  | MAINT | 110 |
| 189 | POLE REPLACEMENTS WORKS | manual | 4d | 2024-06-03 | 2024-06-06 | STRABANE | omagh A | OHL | 110 |
| 190 | TX1 MAJOR AND SHEATH TESTS , NO SFRA | manual | 2w | 2024-06-10 | 2024-06-21 | COOLKEERAGH |  | MAINT | 110 |
| 191 | 7H0 MAINT TX1 | manual | 5d | 2024-06-10 | 2024-06-14 | COOLKEERAGH |  | MAINT | 110 |
| 192 | IBTX2 MAJOR | manual | 3w | 2024-06-10 | 2024-06-28 | BALLYLUMFORD |  | MAINT | 275 |
| 193 | GT2 MD35 and Sheath | manual | 5d | 2024-06-17 | 2024-06-21 | BALLYLUMFORD |  | MAINT | 110 |
| 194 | TX2 MAJOR AND 33KV BUSHINGS AND COOLER DEFECT REPAIRS, NO SFRA | manual | 2w | 2024-06-24 | 2024-07-05 | COOLKEERAGH |  | MAINT | 110 |
| 195 | 9H0 MAINT TX2 | manual | 5d | 2024-06-24 | 2024-06-28 | COOLKEERAGH |  | MAINT | 110 |
| 196 | SNAGGING WORKS | manual | 5d | 2024-07-01 | 2024-07-05 | EDEN | BALLYLUMFORD B | OHL | 110 |
| 197 | SNAGGING WORKS | manual | 5d | 2024-07-01 | 2024-07-05 | EDEN | BALLYLUMFORD A | OHL | 110 |
| 198 | LARNE TX1 BUSHINGS (PROJECTS) - BUSHING CHANGES AND TAPCHANGER REPAIR | manual | 2w | 2024-07-01 | 2024-07-12 | LARNE |  | PROJ | 110 |
| 199 | LARNE TX1 MAJOR | manual | 2w | 2024-07-01 | 2024-07-12 | LARNE |  | MAINT | 110 |
| 200 | A CIRCUIT OUTAGE CLEANING CONDUCTORS 20 SPANS | manual | 2w | 2024-07-01 | 2024-07-12 | COOLKEERAGH | MAGHERAFELT A | OHL | 275 |
| 201 | 33KV CABLE ALTERATIONS ON TX 2 | manual | 2w | 2024-07-03 | 2024-07-16 | ROSEBANK |  | PROJ | 110 |
| 202 | 110KV EARTH SWITCH TX2 | manual | 2w | 2024-07-03 | 2024-07-16 | ROSEBANK |  | PROJ | 110 |
| 203 | NEW LVAC BOARD | manual | 1w | 2024-07-03 | 2024-07-09 | ROSEBANK |  | PROJ | 110 |
| 204 | transformer D oil level guage | manual | 2d | 2024-07-12 | 2024-07-15 | DONEGALL |  | MAINT | 110 |
| 205 | line charactoeristics | manual | 1d | 2022-01-01 | 2022-01-01 | HANNAHSTOWN | BALLYLUMFORD B (and BYC) | MAINT | 275 |
| 206 | earth wire conductor sampling dual circuit outage | manual | 1d | 2022-01-01 | 2022-01-01 | HANNAHSTOWN | CASTLEREAGH A & B | OHL | 275 |
| 207 | VT AND ISOLATORS DUE | manual | 2d | 2024-07-12 | 2024-07-15 | DRUMNAKELLY | TANDRAGEE 'A' | MAINT | 110 |
| 208 | VT AND ISOLATORS DUE | manual | 2d | 2024-07-12 | 2024-07-15 | DRUMNAKELLY | TAMNAMORE 'B' | MAINT | 110 |
| 209 | PUBLIC HOLIDAY | manual | 2d | 2024-07-12 | 2024-07-15 | BANK HOLIDAY/PUBLIC HOLS |  | HOL | SPARE |
| 210 | 15H0 MAINT AND CAP BANK ( weeding only ) | manual | 2d | 2024-07-15 | 2024-07-16 | COOLKEERAGH |  | MAINT | 110 |

| ID | Task | Type | Duration | Start | Finish | Text1 | Text3 | Text4 | Text2 |
| --- | --- | --- | --- | --- | --- | --- | --- | --- | --- |
| 211 | BCM tx A ETX LV ENCLOSURE | manual | 1w | 2024-07-15 | 2024-07-19 | BELFAST CENTRAL MAIN | PROJ | 110 |  |
| 212 | CAS-CRG-BCM A & B START | manual | 6w | 2024-07-15 | 2024-08-23 | CASTLEREAGH | PROJ | 110 | CREGAGH - BELFAST CENTRAL |
| 213 | CAS-CRG-BCM A (PROJECTS) - 3 ENDED PROTECTION | manual | 6w | 2024-07-15 | 2024-08-23 | CASTLEREAGH | PROJ | 110 | CREGAGH - BELFAST CENTRAL 'A' |
| 214 | 8S0 MAINT / REPLACEMENT | manual | 5w | 2024-07-15 | 2024-08-16 | STRABANE | MAINT | 110 |  |
| 215 | LARNE TX2 BUSHINGS (PROJECTS) - BUSHING CHANGES | manual | 2w | 2024-07-16 | 2024-07-29 | LARNE | PROJ | 110 |  |
| 216 | LARNE TX2 MAJOR | manual | 2w | 2024-07-16 | 2024-07-29 | LARNE | MAINT | 110 |  |
| 217 | TOWER PAINTING | manual | 2w | 2024-07-16 | 2024-07-29 | BALLYLUMFORD | OHL | 275 | HANNAHSTOWN B |
| 218 | repair joint on Tower 672 Black/Yellow | manual | 2w | 2024-07-16 | 2024-07-29 | BALLYLUMFORD | OHL | 275 | HANNAHSTOWN B |
| 219 | CVT REPLACEMENT | manual | 0.2w | 2022-01-01 | 2022-01-01 | BALLYLUMFORD | PROJ | 275 | HANNAHSTOWN B |
| 220 | 3C0 MAINT | manual | 3d | 2024-07-16 | 2024-07-18 | CARMONEY | MAINT | 110 |  |
| 221 | MC26 MAINT | manual | 3d | 2024-07-16 | 2024-07-18 | CASTLEREAGH | MAINT | 110 |  |
| 222 | CLIMBING INSPECTIONS / PAINTING/ line raising works | manual | 1w | 2024-07-16 | 2024-07-22 | CASTLEREAGH | OHL | 110 | CARNMONEY A |
| 223 | B CIRCUIT OUTAGES CLEANING CONDUCTORS 20 SPANS | manual | 2w | 2024-07-16 | 2024-07-29 | COOLKEERAGH | OHL | 275 | MAGHERAFELT B |
| 224 | OHL AND TOWER PAINTING | manual | 1w | 2024-07-16 | 2024-07-22 | HANNAHSTOWN | OHL | 275 | BALLYLUMFORD B |
| 225 | line characteristics | manual | 1d | 2024-07-16 | 2024-07-16 | HANNAHSTOWN | MAINT | 275 | BALLYLUMFORD B |
| 226 | 275KV ISOLATORS 3 SETS BPS GG4,GG21,GG22 AND BPS MESH CORNER PROTECTION / DISCONNECT IBTX1 | manual | 15w | 2024-07-16 | 2024-10-28 | HANNAHSTOWN | PROJ | 275 | BPS |
| 227 | EDEN 'A' CVT | manual | 2d | 2024-07-22 | 2024-07-23 | CARMONEY | MAINT | 110 |  |
| 228 | GA55 MAINT MAG B | manual | 1w | 2024-07-22 | 2024-07-26 | COOLKEERAGH | MAINT | 275 |  |
| 229 | GH43 MAINT | manual | 5d | 2024-07-22 | 2024-07-26 | MAGHERAFELT | MAINT | 275 |  |
| 230 | MP30 MAINT TREMOGE | manual | 1w | 2024-07-29 | 2024-08-02 | TAMNAMORE | MAINT | 110 |  |
| 231 | MOYLES ANNUAL MAINTENANCE | manual | 1d? | 2022-01-01 | 2022-01-01 | BALLYCRONANMORE | GEN | 275 |  |
| 232 | IBTX2 MINOR | manual | 1w | 2024-08-05 | 2024-08-09 | KELLS | MAINT | 110 |  |
| 233 | GH5 MAINT BUSCOUPLER | manual | 1w | 2024-08-05 | 2024-08-09 | MAGHERAFELT | MAINT | 275 |  |
| 234 | Protection testing | manual | 1d | 2024-04-08 | 2024-04-08 | SLIEVEKIRK | MAINT | 110 |  |
| 235 | MR99 MAINT AND ESW | manual | 1w | 2024-04-08 | 2024-04-12 | SLIEVEKIRK | MAINT | 110 |  |
| 236 | MP55 MAINT GORT | manual | 1w | 2024-08-05 | 2024-08-09 | TAMNAMORE | MAINT | 110 |  |
| 237 | OHL WORKS | manual | 1w | 2024-08-05 | 2024-08-09 | BALLYLUMFORD | OHL | 110 | EDEN A |
| 238 | 1T0 MAINT | manual | 5d | 2024-08-05 | 2024-08-09 | EDEN | MAINT | 110 |  |
| 239 | 3T0 MAINT | manual | 5d | 2024-08-05 | 2024-08-09 | EDEN | MAINT | 110 |  |
| 240 | 275kv CT BAY TBC | manual | 0.2w | 2022-01-01 | 2022-01-01 | KILROOT | PROJ | 275 |  |
| 241 | 275kv CT BAY TBC | manual | 0.2w | 2022-01-01 | 2022-01-01 | KILROOT | PROJ | 275 |  |
| 242 | TX2 MAJOR INC SFRA | manual | 8d | 2024-08-12 | 2024-08-21 | NEWRY MAIN | MAINT | 110 |  |
| 243 | MB20 MAINT NEWRY B | manual | 1w | 2024-08-12 | 2024-08-16 | TANDRAGEE | MAINT | 110 |  |
| 244 | OHL WORKS | manual | 1w | 2024-08-12 | 2024-08-16 | BALLYLUMFORD | OHL | 110 | EDEN 'B' |
| 245 | 2C0 MAINT | manual | 3d | 2024-08-12 | 2024-08-14 | CARMONEY | MAINT | 110 |  |
| 246 | CAS B CVT MAINT | manual | 2d | 2024-08-12 | 2024-08-13 | CARMONEY | MAINT | 110 |  |
| 247 | CLIMBING INSPECTIONS / PAINTING/ line raising works | manual | 1w | 2024-08-12 | 2024-08-16 | CASTLEREAGH | OHL | 110 | CARNMONEY B |
| 248 | 4T0 MAINT | manual | 4d | 2024-08-12 | 2024-08-15 | EDEN | MAINT | 110 |  |
| 249 | DEFECT REPAIRS T256,T257 & T257A | manual | 1w | 2024-08-12 | 2024-08-16 | MAGHERAFELT | OHL | 275 | TAMNAMORE 'B' |
| 250 | GH65 MAINT TAMANMORE 'B' | manual | 1w | 2024-08-12 | 2024-08-16 | MAGHERAFELT | MAINT | 275 |  |
| 251 | CT, CVT AND CABLE CHARACTERISTICS TESTS | manual | 2d | 2024-08-19 | 2024-08-20 | MULLAVILLY | PROJ | 110 |  |
| 252 | MB30 MAINT MULLAVILLY B/STORAGE | manual | 1w | 2024-08-19 | 2024-08-23 | TANDRAGEE | MAINT | 110 |  |
| 253 | 7S0 REPLACEMENT AND OMAGH B CVT | manual | 7w | 2024-08-19 | 2024-10-04 | STRABANE | PROJ | 110 |  |
| 254 | BCM tx B ETX LV ENCLOSURE | manual | 1w | 2024-08-26 | 2024-08-30 | BELFAST CENTRAL MAIN | PROJ | 110 |  |
| 255 | PUBLIC HOLIDAY | manual | 1d | 2024-08-26 | 2024-08-26 | BANK HOLIDAY/PUBLIC HOLS | HOL | SPARE |  |
| 256 | CAS-CRG-BCM B (PROJECTS) - 3 ENDED PROTECTION | manual | 6w | 2024-08-26 | 2024-10-04 | CASTLEREAGH | PROJ | 110 | CREGAGH - BELFAST CENTRAL 'B' |
| 257 | ESB works at corraclassy and on OHL | manual | 10d | 2024-08-26 | 2024-09-06 | ENNISKILLEN | EIR grid | 110 | Corraclassy |
| 258 | GA75 MAINT IBTX2 | manual | 5d | 2024-08-27 | 2024-08-31 | COOLKEERAGH | MAINT | 275 |  |
| 259 | 3H0 MAINT IBTX2 | manual | 5d | 2024-08-27 | 2024-08-31 | COOLKEERAGH | MAINT | 110 |  |
| 260 | IBTX2 MINOR | manual | 1w | 2024-08-27 | 2024-09-02 | COOLKEERAGH | MAINT | 275 |  |
| 261 | prep works and measurements for diversion | manual | 2d | 2024-09-01 | 2024-09-02 | TREMOGE | OHL | 110 | OMAGH B |
| 262 | DRU (TX1 TAPCHANGER PANELS) - PROJECTS | manual | 4w | 2024-09-02 | 2024-09-27 | DRUMNAKELLY | PROJ | 110 |  |
| 263 | TX1 MAJOR INC SFRA | manual | 8d | 2024-09-02 | 2024-09-11 | MAGHERAKEEL | MAINT | 110 |  |
| 264 | MS20 MAINT | manual | 5d | 2024-09-02 | 2024-09-06 | MAGHERAKEEL | MAINT | 110 |  |
| 265 | MS25 MAINT | manual | 1w | 2024-09-02 | 2024-09-06 | MAGHERAKEEL | MAINT | 110 |  |
| 266 | OHL CONDUCTOR SAMPLES and DLR equipment addition, CVT MAINT | manual | 2.5d | 2024-09-02 | 2024-09-04 | OMAGH | OHL | 110 | MAGHERAKEEL |
| 267 | WINDFARM ANNUAL MAINT . | manual | 1d | 2024-09-02 | 2024-09-02 | BROCKAGHBOY | GEN | 110 |  |
| 268 | TRANSFORMER 2 OUTAGE TO REPAIR EM356 sticking | manual | 2w | 2024-09-02 | 2024-09-13 | GORT | MAINT | 110 |  |
| 269 | OHL WORKS | manual | 1w | 2024-09-09 | 2024-09-13 | BALLYLUMFORD | OHL | 110 | BALLYVALLAGH A |
| 270 | placeholder | manual | 10d | 2024-09-09 | 2024-09-20 | ARVA | EIR grid | 110 | GORTAWEE |
| 271 | 6M0 SF6 LEAK REPAIR | manual | 1w | 2024-09-09 | 2024-09-13 | OMAGH | MAINT | 110 |  |
| 272 | POLE REPLACEMENT WORKS | manual | 1w | 2024-09-09 | 2024-09-13 | STRABANE | OHL | 110 | OMAGH B |
| 273 | TX2 MAJOR INC SFRA | manual | 8d | 2024-09-12 | 2024-09-23 | MAGHERAKEEL | MAINT | 110 |  |
| 274 | MS45 MAINT | manual | 1w | 2024-09-12 | 2024-09-18 | MAGHERAKEEL | MAINT | 110 |  |
| 275 | 110KV CABLE REPLACEMENT TRANSFORMER 2, INSTALL DISCONNECTOR | manual | 4w | 2024-09-16 | 2024-10-11 | ENNISKILLEN | PROJ | 110 |  |
| 276 | MW30 MAINT OMAGH 'A' | manual | 1w | 2024-09-23 | 2024-09-27 | DROMORE | MAINT | 110 |  |
| 277 | OMA - DRO A (OHL WORK) - SNAGGING | manual | 0.2w | 2022-01-01 | 2022-01-01 | OMAGH | OHL | 110 | DROMORE 'A' |
| 278 | DRU (TX3 TAPCHANGER PANELS) - PROJECTS | manual | 4w | 2024-09-30 | 2024-10-25 | DRUMNAKELLY | PROJ | 110 |  |
| 279 | OMA - DRO B (OHL WORK) - SNAGGING | manual | 0.2w | 2022-01-01 | 2022-01-01 | OMAGH | OHL | 110 | DROMORE 'B' |
| 280 | SECTION 2 BUSBAR | manual | 0.2w | 2022-01-01 | 2022-01-01 | TREMOGE | MAINT | 110 |  |

| ID | Task | Type | Duration | Start | Finish | Text1 | Text3 | Text4 | Text2 |
| --- | --- | --- | --- | --- | --- | --- | --- | --- | --- |
| 281 | LINE TRAP REPLACE tuning UNITS AT BYC END OF HAN CIRCUIT | manual | 0.2w | 2022-01-01 | 2022-01-01 | BALLYCRONANMORE | PROJ | 275 |  |
| 282 | 110KV CABLE REPLACMEMENT IBTX1 CABLE | manual | 1d | 2022-01-01 | 2022-01-01 | COOLKEERAGH | PROJ | 275 |  |
| 283 | GJ70/GJ75 BAY PQ MONITOR AND WIRING MODIFCATIONS | manual | 0.2w | 2022-01-01 | 2022-01-01 | KILROOT | PROJ | 275 | TANDRAGEE |
| 284 | TRE - OMA (LINES) - TOWER REPLACEMENT AND LINE DIVERSION/ EARTH WIRE COMPLETION LAST SPAN OVER UNDERCOSSING | manual | 2w | 2024-10-01 | 2024-10-12 | TREMOGE | OHL | 110 | OMAGH B |
| 285 | MC35 MAINT ( IBTX3) | manual | 5d | 2024-10-07 | 2024-10-11 | CASTLEREAGH | MAINT | 110 |  |
| 286 | IBTX3 MINOR | manual | 1w | 2024-10-07 | 2024-10-11 | CASTLEREAGH | MAINT | 275 |  |
| 287 | GP85 MAINT TAN B | manual | 0.2w | 2022-01-01 | 2022-01-01 | TAMNAMORE | MAINT | 275 |  |
| 288 | tower painting | manual | 2w | 2024-10-07 | 2024-10-18 | COOLKEERAGH | OHL | 110 | strabane |
| 289 | TMN- MAG 'A' (OHL WORK) - SINGLE TENSION TOWER 228 & 253 | manual | 0.2w | 2022-01-01 | 2022-01-01 | MAGHERAFELT | OHL | 275 | TAMNAMORE 'A' |
| 290 | GH55 BAY PQ MONITOR AND WIRING MODIFICATIONS | manual | 0.2w | 2022-01-01 | 2022-01-01 | MAGHERAFELT | PROJ | 275 | TAMNAMORE 'A' |
| 291 | 5S0 REPLACEMENT AND CPS B CVT | manual | 0.2w | 2022-01-01 | 2022-01-01 | STRABANE | PROJ | 110 |  |
| 292 | CLOCKCHANGE | manual | 1d | 2024-10-27 | 2024-10-27 | CLOCKCHANGE | TIME | SPARE |  |
| 293 | TX2 BUSHING REPLACEMENT AND BUSBAR COVER REPLACEMENT | manual | 2.2w | 2024-11-01 | 2024-11-15 | BALLYMENA | MAINT | 110 |  |
| 294 | TANDRAGEE MBXX CIRCUIT BREAKER AND CT REPLACEMENT | manual | 0.2w | 2022-01-01 | 2022-01-01 | TANDRAGEE | PROJ | 110 |  |
| 295 | CVT maintaince & test | manual | 1d | 2022-01-01 | 2022-01-01 | HANNAHSTOWN | OHL | 275 | BALLYCRONANMORE |
| 296 | 275KV ISOLATORS BYC CORNER INSTALL BUSBARS FINISH CVT AND LINE TRAPS | manual | 0.2w | 2022-01-01 | 2022-01-01 | HANNAHSTOWN | PROJ | 275 |  |
| 297 | OHL WORKS | manual | 0.2w | 2022-01-01 | 2022-01-01 | STRABANE | PROJ | 110 | COOLKEERAGH 'B' |
| 298 | TX2 LNER | manual | 1d | 2022-01-01 | 2022-01-01 | LISBURN MAIN | MAINT | 110 |  |
| 299 | TX1 LNER | manual | 1d | 2022-01-01 | 2022-01-01 | LISBURN MAIN | MAINT | 110 |  |
| 300 | TX1 LNER | manual | 1d | 2022-01-01 | 2022-01-01 | RATHGAEL | MAINT | 110 |  |
| 301 | TANDRAGEE IBTX3 MINOR AND REPLACE RX3 BUCHOLZ & PRD'S | manual | 0.2w | 2022-01-01 | 2022-01-01 | TANDRAGEE | MAINT | 275 |  |
| 302 | COOLKEERAGH MAIN SECTION 1 (BUSBAR) | manual | 0.2w | 2022-01-01 | 2022-01-01 | COOLKEERAGH | MAINT | 110 |  |
